# wasp

Schedule from MS Project, 2006-06-01 to 2008-01-11.
VAST Lab, UCCS

## Calendars

- Standard: Mon-Fri 08:00-12:00, 13:00-17:00; Sat-Sun off.

## Resources

| Resource |
| --- |
| LeadEng |
| CompanyPI |
| GRA1 |
| SENG |
| PM |
| PostDoc |
| GRA2 |
| PI |
| Boult |

## Schedule

| ID | WBS | Task | Duration | Start | Finish | Predecessors | Total slack | Free slack | Constraint | Resources | Work |
| --- | --- | --- | --- | --- | --- | --- | --- | --- | --- | --- | --- |
| 1 | 1 | Project Start | 2.67d? | 2006-06-01 | 2006-06-09 |  | 0d |  | start no earlier than 2006-06-01 | CompanyPI [50%]; PM | 16h |
| 2 | 2 | **Base Effort** | 421.95d? | 2006-06-01 | 2008-01-11 |  | 0d |  |  |  | 8804.95h |
| 3 | 2.1 | **T1** | 415.87d | 2006-06-09 | 2008-01-11 |  | 0d |  |  |  | 1825h |
| 4 | 2.1.1 | Step1 | 2.9mo | 2006-06-09 | 2006-08-30 | 1 | 0d |  |  | PI [10%]; PostDoc | 360h |
| 5 | 2.1.2 | Step2 | 6.23mo | 2006-08-30 | 2007-03-07 | 4 | 0d |  | start no earlier than 2006-06-01 | PI [3%]; PostDoc; GRA2 [50%] | 400h |
| 6 | 2.1.3 | Step3 | 2.81mo | 2007-03-07 | 2007-05-24 | 5 | 0d |  | start no earlier than 2006-06-01 | PostDoc [50%] | 225h |
| 7 | 2.1.4 | Step4 | 6.68mo | 2007-05-24 | 2007-11-28 | 6 | 0d |  | start no earlier than 2006-06-01 | PI [2%]; PostDoc; GRA1 [50%] | 640h |
| 8 | 2.1.5 | Step5 | 1.64mo | 2007-11-28 | 2008-01-11 | 7 | 0d |  | start no earlier than 2006-06-01 | PI [5%]; PostDoc [50%]; GRA2 [50%] | 200h |
| 9 | 2.2 | **Recognition Mode** | 382.85d | 2006-06-01 | 2007-11-19 |  | 39.1d |  |  |  | 1180h |
| 10 | 2.2.1 | Build 2 vehicle training set for CHW | 29.29d | 2006-09-14 | 2006-11-21 | 30 | 39.1d | 0d |  | PI [2%]; GRA1 [50%] | 120h |
| 11 | 2.2.2 | Analyze/test Vehicle CHW on UAV video | 44.12d | 2006-11-21 | 2007-05-17 | 10 | 171.07d |  |  | GRA1 [50%]; PI [2%] | 120h |
| 12 | 2.2.3 | Build SUAV training set for CHW | 19.24d | 2006-06-01 | 2006-12-26 |  | 53.53d | 0d | start no earlier than 2006-06-01 | SENG; CompanyPI [2%]; LeadEng [30%] | 120h |
| 13 | 2.2.4 | Analyze/test SUAV CHW on UAV video | 45d | 2006-12-26 | 2007-10-30 | 12 | 53.53d |  |  | SENG [50%] | 180h |
| 14 | 2.2.5 | Build human training set CHW | 39.22d | 2006-11-21 | 2007-01-15 | 10 | 39.1d | 0d |  | GRA1 [25%]; PI [2%] | 80h |
| 15 | 2.2.6 | Analyze/test Human CHW on UAV video | 59.01d | 2007-01-15 | 2007-04-06 | 14 | 39.1d | 0d |  | GRA1 [50%]; PI [2%] | 200h |
| 16 | 2.2.7 | Test CHW-based recognition in FPGA | 41.38d | 2007-04-06 | 2007-06-04 | 15 | 39.1d | 0d |  | CompanyPI [5%]; LeadEng [35%] | 120h |
| 17 | 2.2.8 | PC-based boosted Classifier Interface | 120d | 2007-06-04 | 2007-11-19 | 16 | 39.1d |  | start no earlier than 2006-07-27 | CompanyPI [12.5%]; LeadEng [35%] | 240h |
| 18 | 2.3 | **FPGA Accelerated Wide-Area** | 417.6d? | 2006-06-01 | 2008-01-07 |  | 4.35d |  |  |  | 5799.94h |
| 19 | 2.3.1 | Background-modeling in FPGA | 44.12d? | 2006-08-30 | 2006-10-31 | 4 | 33.32d | 0d | start no earlier than 2006-06-01 | CompanyPI [10%]; SENG [50%]; LeadEng [50%] | 300h |
| 20 | 2.3.2 | QCC Analysis | 43.08d? | 2006-10-31 | 2007-01-01 | 19 | 33.32d | 0d | start no earlier than 2006-06-01 | CompanyPI [10%]; LeadEng; SENG [50%] | 280h |
| 21 | 2.3.3 | QCC in FPGA/Eltax | 76.47d? | 2007-01-01 | 2007-04-18 | 20 | 33.32d | 26.27d | start no earlier than 2006-06-01 | CompanyPI [10%]; LeadEng [30%]; SENG [50%] | 480h |
| 22 | 2.3.4 | Dual-Thresholding | 93.18d? | 2007-05-24 | 2007-10-31 | 6, 21 | 7.06d | 0d | start no earlier than 2006-06-01 | CompanyPI [10%]; LeadEng [25%]; SENG [40%] | 300h |
| 23 | 2.3.5 | Geo-Location via static calibration | 45.45d? | 2007-10-31 | 2008-01-02 | 22 | 7.06d |  | start no earlier than 2006-06-01 | CompanyPI [10%]; SENG [50%] | 200h |
| 24 | 2.3.6 | IOU FPGA Tradeoff study | 43.22d? | 2007-02-16 | 2007-04-18 | 39 | 4.35d | 0d | start no earlier than 2006-06-01 | CompanyPI [10%]; LeadEng [30%]; SENG [30%] | 140h |
| 25 | 2.3.7 | Implement IOU Tracking (ground based) | 56.16d | 2007-04-18 | 2007-11-06 | 24 | 4.35d | 0d | start no earlier than 2006-06-01 | LeadEng [20%]; CompanyPI [5%]; SENG [50%] | 180h |
| 26 | 2.3.8 | IOU FPGA (UAV) | 44.44d? | 2007-11-06 | 2008-01-07 | 25 | 4.35d |  | start no earlier than 2006-06-01 | CompanyPI [15%]; LeadEng [30%]; SENG [50%] | 240h |

| ID | WBS | Task | Type | Duration | Start | Finish | Predecessors | Total slack | Free slack | Constraint | Resources | Work |
| --- | --- | --- | --- | --- | --- | --- | --- | --- | --- | --- | --- | --- |
| 27 | 2.3.9 | **UAV Tracking Mode** |  | 414.35d? | 2006-06-01 | 2008-01-02 |  | 4.35d |  |  |  | 2513.95h |
| 28 | 2.3.9.1 | Literature Research |  | 20d | 2006-06-09 | 2006-07-07 |  | 39.1d | 0d | start no earlier than 2006-06-01 | LeadEng [44.1%]; CompanyPI [5.9%] | 80h |
| 29 | 2.3.9.2 | SHP in software |  | 21.3d | 2006-07-07 | 2006-08-07 | 28 | 140.51d | 27.72d |  | CompanyPI [25%]; LeadEng [35%]; SENG | 240h |
| 30 | 2.3.9.3 | Build dismounted human training set for SHP |  | 49.02d | 2006-07-07 | 2006-09-14 | 28 | 39.1d | 0d |  | GRA1 [50%]; PI [2%] | 200h |
| 31 | 2.3.9.4 | Test SHP on UAV video for dismounts |  | 40.59d | 2006-09-14 | 2007-01-29 | 29, 30 | 112.79d | 0d |  | PI [2%]; GRA1 [50%] | 120h |
| 32 | 2.3.9.5 | Demonstrate re-identification of a dismount in clutter |  | 38.46d | 2007-01-29 | 2007-06-14 | 31 | 112.79d | 0d | finish no earlier than 2006-11-15 | PI [2%]; GRA1 [50%] | 80h |
| 33 | 2.3.9.6 | Build Vehicle training set for SHP |  | 11.61d | 2007-06-14 | 2007-06-29 | 32 | 112.79d | 0d | start no earlier than 2006-06-01 | PI [2%]; GRA2 [50%]; PostDoc | 120h |
| 34 | 2.3.9.7 | Test SHP on UAV video for vehicles |  | 21.97d | 2007-06-29 | 2007-08-08 | 33 | 112.79d |  |  | PI [2%]; GRA1 [50%]; GRA2 [50%] | 79.99h |
| 35 | 2.3.9.8 | Analyze mapping of SHP to FPGA |  | 46.64d? | 2007-01-29 | 2007-04-04 | 31 | 145.76d | 0d |  | CompanyPI [5.1%]; LeadEng [35.1%] | 150h |
| 36 | 2.3.9.9 | Analyze Matching in FPGA/ETRAX |  | 56.39d | 2007-04-04 | 2007-06-22 | 35 | 145.76d |  |  | CompanyPI [15%]; LeadEng [35%] | 190h |
| 37 | 2.3.9.10 | Implement IOU Tracking (UAV based) software |  | 48.95d | 2006-06-01 | 2006-08-08 |  | 4.35d | 0d | start no earlier than 2006-06-01 | PostDoc; PI [5%]; GRA2 [50%] | 400h |
| 38 | 2.3.9.11 | Implement RTF multi-hypothesis |  | 38.57d | 2006-08-08 | 2006-10-02 | 37 | 4.35d | 0d | start no earlier than 2006-06-01 | PostDoc; PI [5%]; GRA2 [50%] | 240h |
| 39 | 2.3.9.12 | Integrate RFT IOU for ground vehicles |  | 37.95d? | 2006-10-02 | 2007-02-16 | 38 | 4.35d | 0d |  | PostDoc; PI [10%] | 333.95h |
| 40 | 2.3.9.13 | Integrate RFT IOU for SUAVs |  | 27.93d? | 2007-02-16 | 2007-07-13 | 39 | 7.6d | 0d |  | SENG; CompanyPI [10%] | 200h |
| 41 | 2.3.9.14 | Computer RFT IOU with Condensation-based MHT |  | 29.41d? | 2007-07-13 | 2008-01-02 | 40 | 7.6d |  |  | GRA1 [50%]; PI [2%] | 80h |
| 44 | 2.3.10 | **Identification Mode** |  | 154.03d | 2006-06-01 | 2007-01-03 |  | 18.12d |  |  |  | 160h |
| 45 | 2.3.10.1 | Step I1 |  | 73.72d | 2006-06-01 | 2007-01-03 |  | 18.12d | 0d | start no earlier than 2006-06-01 | PI [5%]; GRA2 [49%] | 160h |
| 46 | 2.3.11 | Stepi2 |  | 55.96d? | 2007-01-03 | 2007-03-21 | 45 | 18.12d | 0d | start no earlier than 2006-06-01 | PI [10%]; GRA2 [49%] | 160h |
| 47 | 2.3.12 | Stepi3 |  | 174.25d? | 2007-03-21 | 2007-12-18 | 46 | 18.12d |  |  | SENG; CompanyPI [5%] | 200h |
| 49 | 2.3.13 | **Network Architecture** |  | 402.04d? | 2006-06-09 | 2007-12-25 |  | 13.83d |  |  |  | 646h |
| 50 | 2.3.13.1 | Tradeoff study |  | 92.07d? | 2006-08-15 | 2007-01-26 |  | 62.63d | 0d | start no earlier than 2006-08-15 | PI [15%]; PostDoc [15%] | 120h |
| 51 | 2.3.13.2 | Initial Design |  | 187.5d? | 2007-01-26 | 2007-10-17 | 50 | 62.63d | 0d | start no earlier than 2006-06-01 | PI [10%]; PostDoc [15%] | 300h |
| 52 | 2.3.13.3 | Adaptive Bandwidth analysis | milestone | 0d? | 2007-10-17 | 2007-10-17 | 51 | 62.63d |  | start no earlier than 2006-06-01 | PI [10%]; PostDoc [15%] |  |
| 54 | 2.3.13.4 | General PM and reporting |  | 16.41mo | 2006-09-21 | 2007-12-25 | 1 | 13.83d |  | start no earlier than 2006-09-21 | PM [8%] | 210h |
| 55 | 2.3.13.5 | Kickoff briefing |  | 10d? | 2006-06-09 | 2006-06-23 | 1 | 405.87d |  |  | CompanyPI [20%] | 16h |
